# Chime Deployment Overview

Schedule from MS Project, 2021-05-24 to 2021-06-11.

## Calendars

- Standard: Mon-Fri 08:00-12:00, 13:00-17:00; Sat-Sun off.

## Resources

| Resource |
| --- |
| Management |
| Project Manager |
| Analyst |
| Developer |
| Testers |
| Trainers |
| Technical Communicators |
| Deployment Team |

## Schedule

| ID | WBS | Task | Duration | Start | Finish | Predecessors | Total slack | Free slack | Resources | Work |
| --- | --- | --- | --- | --- | --- | --- | --- | --- | --- | --- |
| 1 | 1 | **Determine scope & review Azure and 0365 Pre Reqs** | 4.55d? | 2021-05-24 08:00 | 2021-05-28 13:24 |  | 4.1d |  |  | 16h |
| 2 | 1.1 | Determine project scope - Number queues, languages required | 5h | 2021-05-24 08:00 | 2021-05-24 14:00 |  | 4.1d | 0d | Management | 5h |
| 3 | 1.2 | Determine admin, manager, and agents access | 3h | 2021-05-24 14:00 | 2021-05-24 17:00 | 2 | 4.1d | 0d | Management | 3h |
| 4 | 1.3 | Determine queue(s) and queue membership | 0.25d? | 2021-05-25 08:00 | 2021-05-25 10:00 | 3 | 4.1d | 0d |  |  |
| 5 | 1.4 | Estimate inbound chat load (daily, weekly) | 2h | 2021-05-25 10:00 | 2021-05-25 12:00 | 4 | 4.1d | 0d |  |  |
| 6 | 1.5 | Determine machine and DB spec - based on projected load | 0.5d | 2021-05-25 13:00 | 2021-05-25 17:00 | 5 | 4.1d | 0d | Project Manager | 4h |
| 7 | 1.6 | Review 0365 graph persmissions with 0365 admin | 0.5d | 2021-05-26 08:00 | 2021-05-26 12:00 | 6 | 4.1d | 0d | Project Manager | 4h |
| 8 | 1.7 | Azure front door configuration and firewalls | 0.3d? | 2021-05-26 13:00 | 2021-05-26 15:24 | 7 | 4.1d | 0d |  |  |
| 9 | 1.8 | Azure bot framework service review & creation | 0.25d | 2021-05-26 15:24 | 2021-05-27 08:24 | 8 | 4.1d | 0d |  |  |
| 10 | 1.9 | Review and confirm 0365 tenant persmission with 0635 admin | 0.25d? | 2021-05-27 08:24 | 2021-05-27 10:24 | 9 | 4.1d | 0d |  |  |
| 11 | 1.10 | Discuss any ticketing integration | 2h | 2021-05-27 10:24 | 2021-05-27 13:24 | 10 | 4.1d | 0d |  |  |
| 12 | 1.11 | Acquire SSL Cert (order) | 1d? | 2021-05-27 13:24 | 2021-05-28 13:24 | 11 | 4.1d | 0d |  |  |
| 13 | 2 | **Install Azure resources and Chime instance** | 2.23d | 2021-05-28 13:24 | 2021-06-01 15:15 |  | 4.1d |  |  | 21.6h |
| 14 | 2.1 | Create host VM | 0.25d | 2021-05-28 13:24 | 2021-05-28 15:24 | 12 | 4.1d | 0d | Analyst | 2h |
| 15 | 2.2 | Configure Azure SQL DB | 0.25d | 2021-05-28 15:24 | 2021-05-31 08:24 | 14 | 4.1d | 0d | Analyst | 2h |
| 16 | 2.3 | Create bot framework bots | 0.2d | 2021-05-31 08:24 | 2021-05-31 10:00 | 15 | 4.1d | 0d | Project Manager | 1.6h |
| 17 | 2.4 | Download and install Chime | 4h | 2021-05-31 10:00 | 2021-05-31 15:00 | 16 | 4.1d | 0d | Project Manager; Analyst | 8h |
| 18 | 2.5 | Apply SSL during install | 1h | 2021-05-31 15:00 | 2021-05-31 16:00 | 17 | 4.1d | 0d | Analyst | 1h |
| 19 | 2.6 | Configure email settings | 1h | 2021-05-31 16:00 | 2021-05-31 17:00 | 18 | 4.1d | 0d | Project Manager | 1h |
| 20 | 2.7 | Verify port 443 access | 1h | 2021-06-01 08:00 | 2021-06-01 09:00 | 19 | 4.1d | 0d | Management; Project Manager | 2h |
| 21 | 2.8 | Configure Azure Front Door or other Gateway | 0.5d | 2021-06-01 09:00 | 2021-06-01 14:00 | 20 | 4.1d | 0d | Project Manager | 4h |
| 22 | 2.9 | Cross authenticate Chime with 0365 tenant via callback | 1h | 2021-06-01 14:00 | 2021-06-01 15:00 | 21 | 4.1d | 0d |  |  |
| 23 | 2.10 | Start Chime and verify installation | 0.25h | 2021-06-01 15:00 | 2021-06-01 15:15 | 22 | 4.1d | 0d |  |  |
| 24 | 3 | **Configure Chime Application** | 1.12d | 2021-06-01 15:15 | 2021-06-02 16:12 |  | 4.1d |  |  | 5.2h |
| 25 | 3.1 | Add license keys | 1h | 2021-06-01 15:15 | 2021-06-01 16:15 | 23 | 4.1d | 0d | Analyst | 1h |
| 26 | 3.2 | Add admin users and managers | 0.5h | 2021-06-01 16:15 | 2021-06-01 16:45 | 25 | 4.1d | 0d | Analyst | 0.5h |
| 27 | 3.3 | Add agents to admin area | 2h | 2021-06-01 16:45 | 2021-06-02 09:45 | 26 | 4.1d | 0d | Analyst | 2h |
| 28 | 3.4 | Add bot framework instances\info to dispatcher list | 2h | 2021-06-02 09:45 | 2021-06-02 11:45 | 27 | 4.1d | 0d |  |  |
| 29 | 3.5 | Provide default graphic for web client | 0.2h | 2021-06-02 11:45 | 2021-06-02 11:57 | 28 | 4.1d | 0d | Management | 0.2h |
| 30 | 3.6 | Configure email notifications for health monitoring | 1h | 2021-06-02 11:57 | 2021-06-02 13:57 | 29 | 4.1d | 0d | Management | 1h |
| 31 | 3.7 | Review health monitoring area | 0.25h | 2021-06-02 13:57 | 2021-06-02 14:12 | 30 | 4.1d | 0d | Management; Project Manager | 0.5h |
| 32 | 3.8 | Configure language translation access | 2h | 2021-06-02 14:12 | 2021-06-02 16:12 | 31 | 4.1d | 0d |  |  |

| ID | WBS | Task | Type | Duration | Start | Finish | Predecessors | Total slack | Free slack | Resources | Work |
| --- | --- | --- | --- | --- | --- | --- | --- | --- | --- | --- | --- |
| 33 | 4 | **Configure Queue(s)** |  | 2.5d | 2021-06-02 16:12 | 2021-06-07 11:12 |  | 4.1d |  |  | 7.5h |
| 34 | 4.1 | Create queue and assign license key |  | 0.5h | 2021-06-02 16:12 | 2021-06-02 16:42 | 32 | 4.1d | 0d | Developer | 0.5h |
| 35 | 4.2 | Add managers to queue |  | 1h | 2021-06-02 16:42 | 2021-06-03 08:42 | 34 | 4.1d | 0d | Developer | 1h |
| 36 | 4.3 | Add agents to queue & assign skills, priority |  | 2h | 2021-06-03 08:42 | 2021-06-03 10:42 | 35 | 4.1d | 0d | Developer | 2h |
| 37 | 4.4 | Add bot framework end point(s) for concurrency |  | 1h | 2021-06-03 10:42 | 2021-06-03 11:42 | 36 | 4.1d | 0d |  |  |
| 38 | 4.5 | Review text resources and update adaptive cards |  | 1d | 2021-06-03 11:42 | 2021-06-04 11:42 | 37 | 4.1d | 0d |  |  |
| 39 | 4.6 | Review HTML info for web client deployment |  | 1h | 2021-06-04 11:42 | 2021-06-04 13:42 | 38 | 4.1d | 0d |  |  |
| 40 | 4.7 | Apply branding to adaptive cards |  | 2h | 2021-06-04 13:42 | 2021-06-04 15:42 | 39 | 4.1d | 0d |  |  |
| 41 | 4.8 | Add some standard replies |  | 2h | 2021-06-04 15:42 | 2021-06-07 08:42 | 40 | 4.1d | 0d |  |  |
| 42 | 4.9 | Optionally add skill tags |  | 2h | 2021-06-07 08:42 | 2021-06-07 10:42 | 41 | 4.1d | 0d | Developer | 2h |
| 43 | 4.10 | Review configuration using web client |  | 2h | 2021-06-07 09:12 | 2021-06-07 11:12 | 42FS-7.5% | 4.1d | 0d | Developer | 2h |
| 44 | 4.11 | Development complete | milestone | 0d | 2021-06-07 11:12 | 2021-06-07 11:12 | 43 | 4.1d | 1.85d |  |  |
| 45 | 5 | **Testing** |  | 3d | 2021-06-07 08:00 | 2021-06-09 17:00 |  |  |  |  | 6h |
| 46 | 5.1 | Test queue using MS Teams |  | 0.5d | 2021-06-07 08:00 | 2021-06-07 12:00 | 32 | 4.25d |  | Testers | 4h |
| 47 | 5.2 | Test queue using web client |  | 0.25d | 2021-06-07 08:00 | 2021-06-07 10:00 | 32 | 4.5d |  | Testers | 2h |
| 48 | 5.3 | Test with agents and MS Teams notifications and accept |  | 0.5d | 2021-06-07 08:00 | 2021-06-07 12:00 |  | 4.25d |  |  |  |
| 49 | 5.4 | Agents accepting chats using agent web client |  | 0.5d | 2021-06-07 08:00 | 2021-06-07 12:00 |  | 4.25d |  |  |  |
| 50 | 6 | **Training** |  | 2.75d | 2021-06-09 08:00 | 2021-06-11 15:00 |  |  |  |  | 8h |
| 51 | 6.1 | Training for managers |  | 2h | 2021-06-09 08:00 | 2021-06-09 10:00 | 32 | 2.25d | 0d | Trainers | 2h |
| 52 | 6.2 | Training for agents |  | 2h | 2021-06-09 08:00 | 2021-06-09 10:00 | 32 | 2.25d | 0d | Trainers | 2h |
| 53 | 6.3 | Managers to review reports and dashboards |  | 2h | 2021-06-09 08:00 | 2021-06-09 10:00 | 32 | 2.25d | 0d | Trainers | 2h |
| 54 | 6.4 | Training for admins |  | 2h | 2021-06-09 10:00 | 2021-06-09 12:00 | 51, 44, 52, 53 | 2.25d |  | Trainers | 2h |
